# 斜井150m进度提前2个月(增加10天)

Schedule from MS Project, 2004-10-08 to 2007-04-08.
21

## Calendars

- 标准: Mon-Sun 08:00-12:00, 13:00-17:00.

## Schedule

| ID | WBS | Task | Type | Duration | Start | Finish | Predecessors | Total slack | Free slack | Constraint |
| --- | --- | --- | --- | --- | --- | --- | --- | --- | --- | --- |
| 1 | 1 | 开工 | milestone | 0d | 2004-10-08 | 2004-10-08 |  | 0d |  | start no earlier than 2004-10-08 |
| 2 | 2 | 施工准备 |  | 44d | 2004-10-08 | 2004-11-20 | 1 | 0d |  |  |
| 3 | 3 | **路基施工** |  | 639d | 2004-11-21 | 2006-08-21 |  | 199d |  |  |
| 4 | 3.1 | 路基挖方 |  | 182d | 2004-11-21 | 2005-05-21 | 2 | 679d |  |  |
| 5 | 3.2 | 路基填筑 |  | 608d | 2004-11-21 | 2006-07-21 | 2 | 169d | 0d |  |
| 6 | 3.3 | 路基附属工程 |  | 503d | 2005-04-06 | 2006-08-21 | 5FS-472d | 169d |  |  |
| 7 | 3.4 | 互通式立交施工 |  | 602d | 2004-11-21 | 2006-07-15 | 2 | 236d |  |  |
| 8 | 4 | **桥梁工程** |  | 710d | 2004-11-21 | 2006-10-31 |  | 0d |  |  |
| 9 | 4.1 | 曹娥江特大桥基础及墩台身、顶帽施工 |  | 161d | 2004-11-21 | 2005-04-30 | 2 | 0d |  |  |
| 10 | 4.2 | 3座中桥基础及墩台身、顶帽 |  | 150d | 2005-01-27 | 2005-06-25 | 9FS-94d | 395d | 0d |  |
| 11 | 4.3 | 2座小桥基础及墩台身、顶帽 |  | 76d | 2005-04-01 | 2005-06-15 | 10FS-86d | 405d |  |  |
| 12 | 4.4 | 梁体预制 |  | 540d | 2005-02-01 | 2006-07-25 | 9FS-89d | 0d |  |  |
| 13 | 4.5 | 梁体架设 |  | 504d | 2005-03-15 | 2006-07-31 | 12FS-498d, 11FF | 0d |  |  |
| 14 | 4.6 | 桥面系 |  | 92d | 2006-08-01 | 2006-10-31 | 13 | 0d |  |  |
| 15 | 5 | 涵洞及通道 |  | 253d | 2004-11-21 | 2005-07-31 | 2 | 549d |  |  |
| 16 | 6 | 其它工程 |  | 128d | 2006-11-01 | 2007-03-08 | 14, 7FF | 0d |  |  |
| 17 | 7 | 竣工验收 |  | 31d | 2007-03-09 | 2007-04-08 | 16, 15, 4, 6 | 0d |  |  |
| 18 | 8 | 竣工 | milestone | 0d | 2007-04-08 | 2007-04-08 | 17 | 0d |  |  |
